# احداث مجموعه ورزشی

Schedule from MS Project, 2013-04-21 to 2015-07-15, status date 2013-05-20, costs in ریال.

## Calendars

- Standard: Mon-Sun 08:00-12:00, 13:00-17:00.

## Schedule

| ID | WBS | Task | Type | Duration | Start | Finish | Predecessors | Baseline start | Baseline finish | Baseline duration | Total slack | Free slack | Cost | Text1 | IN | OUT |
| --- | --- | --- | --- | --- | --- | --- | --- | --- | --- | --- | --- | --- | --- | --- | --- | --- |
| 1 | 1 | شروع پروژه (تحویل زمین) | milestone | 0d | 2013-04-21 | 2013-04-21 |  |  |  |  | 0d |  |  | 0% | 92/2/1 | 92/2/1 |
| 2 | 2 | تجهیز کارگاه |  | 30d | 2013-04-21 | 2013-05-20 | 1 |  |  |  | 786d |  | 36,000,000,000 | 0% | 92/2/1 | 92/2/30 |
| 3 | 3 | **طراحی و گودبرداری** |  | 75d | 2013-04-21 | 2013-07-04 |  | 2008-03-24 | 2008-07-21 | 120d | 0d |  | 14,774,400,000 | 0% |  |  |
| 4 | 3.1 | خاکبرداری |  | 45d | 2013-04-21 | 2013-06-04 | 1 | 2008-03-24 | 2008-05-22 | 60d | 0d |  | 7,387,200,000 | 0% | 92/2/1 | 92/3/14 |
| 5 | 3.2 | تسطیح و رگلاژ زمین |  | 45d | 2013-05-21 | 2013-07-04 | 4SS+30d | 2008-05-23 | 2008-07-21 | 60d | 0d |  | 7,387,200,000 | 0% | 92/2/31 | 92/4/13 |
| 6 | 4 | **فونداسیون** |  | 85d | 2013-05-31 | 2013-08-23 |  | 2008-07-22 | 2009-03-18 | 240d | 0d |  | 33,242,400,000 | 0% |  |  |
| 7 | 4.1 | اجرای بتن مگر |  | 45d | 2013-05-31 | 2013-07-14 | 5SS+10d | 2008-07-22 | 2008-09-19 | 60d | 0d |  | 7,387,200,000 | 0% | 92/3/10 | 92/4/23 |
| 8 | 4.2 | اجرای آرماتوربندی فونداسیون |  | 45d | 2013-06-05 | 2013-07-19 | 7SS+5d | 2008-09-20 | 2008-11-18 | 60d | 0d |  | 7,387,200,000 | 0% | 92/3/15 | 92/4/28 |
| 9 | 4.3 | اجرای قالب‌بندی فونداسیون |  | 45d | 2013-06-10 | 2013-07-24 | 8SS+5d | 2008-11-19 | 2009-01-17 | 60d | 0d |  | 7,387,200,000 | 0% | 92/3/20 | 92/5/2 |
| 10 | 4.4 | اجرای بتن‌ریزی فونداسیون |  | 45d | 2013-06-20 | 2013-08-03 | 9SS+10d | 2009-01-18 | 2009-02-16 | 30d | 0d |  | 7,387,200,000 | 0% | 92/3/30 | 92/5/12 |
| 11 | 4.5 | گروت ریزی و نصب صفحه ستون |  | 20d | 2013-08-04 | 2013-08-23 | 10 | 2009-02-17 | 2009-03-18 | 30d | 0d |  | 3,693,600,000 | 0% | 92/5/13 | 92/6/1 |
| 12 | 5 | **اسکلت** |  | 280d | 2013-08-24 | 2014-05-30 |  | 2009-03-19 | 2010-11-08 | 600d | 0d |  | 66,420,000,000 | 0% |  |  |
| 13 | 5.1 | اجرای بیس پلیت ستونها |  | 45d | 2013-08-24 | 2013-10-07 | 11 | 2009-03-19 | 2009-05-17 | 60d | 0d |  | 7,387,200,000 | 0% | 92/6/2 | 92/7/15 |
| 14 | 5.2 | ساخت و نصب ستون ها |  | 90d | 2013-09-23 | 2013-12-21 | 13SS+30d | 2009-05-18 | 2009-09-14 | 120d | 0d |  | 14,742,000,000 | 0% | 92/7/1 | 92/9/30 |
| 15 | 5.3 | ساخت و نصب تیرهای زنبوری و حمال |  | 90d | 2013-11-22 | 2014-02-19 | 14SS+60d | 2009-09-15 | 2010-01-12 | 120d | 0d |  | 14,742,000,000 | 0% | 92/9/1 | 92/11/30 |
| 16 | 5.4 | ساخت و نصب بادبندها |  | 45d | 2014-01-21 | 2014-03-06 | 15FS-30d | 2010-03-14 | 2010-05-12 | 60d | 0d |  | 7,387,200,000 | 0% | 92/11/1 | 92/12/15 |
| 17 | 5.5 | اجرای سقف شیبدار |  | 70d | 2014-02-20 | 2014-04-30 | 16SS+30d | 2010-05-13 | 2010-08-10 | 90d | 0d |  | 11,080,800,000 | 0% | 92/12/1 | 93/2/10 |
| 18 | 5.6 | اتصالات،جوشکاری و ضدزنگ |  | 70d | 2014-03-22 | 2014-05-30 | 17SS+30d | 2010-08-11 | 2010-11-08 | 90d | 0d |  | 11,080,800,000 | 0% | 93/1/2 | 93/3/9 |
| 19 | 6 | **سفت کاری** |  | 160d | 2014-04-06 | 2014-09-12 |  | 2010-11-09 | 2011-11-03 | 360d | 0d |  | 44,323,200,000 | 0% |  |  |
| 20 | 6.1 | خاکریزی پی و پشت دیوارها |  | 70d | 2014-04-06 | 2014-06-14 | 18SS+15d | 2010-11-09 | 2011-02-06 | 90d | 0d |  | 11,080,800,000 | 0% | 93/1/17 | 93/3/24 |
| 21 | 6.2 | اجرای دیوارچینی |  | 70d | 2014-05-06 | 2014-07-14 | 20SS+30d | 2011-02-07 | 2011-05-07 | 90d | 0d |  | 11,080,800,000 | 0% | 93/2/16 | 93/4/23 |
| 22 | 6.3 | ساخت ساب فریم درها و پنجره ها |  | 70d | 2014-06-05 | 2014-08-13 | 21SS+30d | 2011-05-08 | 2011-08-05 | 90d | 0d |  | 11,080,800,000 | 0% | 93/3/15 | 93/5/22 |
| 23 | 6.4 | نصب ساب فریم و درها و پنجره ها |  | 70d | 2014-07-05 | 2014-09-12 | 22SS+30d | 2011-08-06 | 2011-11-03 | 90d | 0d |  | 11,080,800,000 | 0% | 93/4/14 | 93/6/21 |
| 24 | 7 | **سقف سازی** |  | 330d | 2013-11-22 | 2014-10-17 |  | 2009-10-15 | 2010-09-09 | 330d | 91d |  | 40,338,000,000 | 0% |  |  |
| 25 | 7.1 | ساخت تیرچه های فلزی |  | 90d | 2013-11-22 | 2014-02-19 | 15SS | 2009-10-15 | 2010-01-12 | 90d | 91d | 0d | 11,080,800,000 | 0% | 92/9/1 | 92/11/30 |
| 26 | 7.2 | اجرای سقف |  | 150d | 2014-02-20 | 2014-07-19 | 25 | 2010-01-13 | 2010-06-11 | 150d | 91d | 0d | 18,176,400,000 | 0% | 92/12/1 | 93/4/28 |
| 27 | 7.3 | اجرای کنسولها و پله ها |  | 90d | 2014-07-20 | 2014-10-17 | 26 | 2010-06-12 | 2010-09-09 | 90d | 91d | 0d | 11,080,800,000 | 0% | 93/4/29 | 93/7/25 |

| ID | WBS | Task | Type | Duration | Start | Finish | Predecessors | Baseline start | Baseline finish | Baseline duration | Total slack | Free slack | Cost | Text1 | IN | OUT |
| --- | --- | --- | --- | --- | --- | --- | --- | --- | --- | --- | --- | --- | --- | --- | --- | --- |
| 28 | 8 | **نازک کاری** |  | 270d | 2014-08-24 | 2015-05-20 |  | 2011-11-04 | 2013-04-26 | 540d | 0d |  | 66,484,800,000 | 0% |  |  |
| 29 | 8.1 | نصب درب و پنجره وشیشه |  | 45d | 2014-08-24 | 2014-10-07 | 23SS+50d | 2011-11-04 | 2012-01-02 | 60d | 0d |  | 7,387,200,000 | 0% | 93/6/2 | 93/7/15 |
| 30 | 8.2 | سفيدکاری |  | 70d | 2014-09-23 | 2014-12-01 | 29SS+30d | 2012-01-03 | 2012-04-01 | 90d | 0d |  | 11,080,800,000 | 0% | 93/7/1 | 93/9/10 |
| 31 | 8.3 | زیرسازی و بتونه کشی دیوارها |  | 70d | 2014-10-23 | 2014-12-31 | 30SS+30d | 2012-04-02 | 2012-06-30 | 90d | 0d |  | 11,080,800,000 | 0% | 93/8/1 | 93/10/10 |
| 32 | 8.4 | عایق کاری سرویس ها |  | 60d | 2014-11-22 | 2015-01-20 | 31SS+30d | 2012-07-01 | 2012-08-29 | 60d | 40d | 0d | 7,387,200,000 | 0% | 93/9/1 | 93/10/30 |
| 33 | 8.5 | عایق کاری بام |  | 60d | 2014-12-22 | 2015-02-19 | 32SS+30d | 2012-08-30 | 2012-10-28 | 60d | 40d | 0d | 7,387,200,000 | 0% | 93/10/1 | 93/11/30 |
| 34 | 8.6 | کفسازی سرویس |  | 60d | 2015-01-21 | 2015-03-21 | 33SS+30d | 2012-10-29 | 2012-12-27 | 60d | 40d | 0d | 7,387,200,000 | 0% | 93/11/1 | 94/1/1 |
| 35 | 8.7 | کفسازی بام |  | 60d | 2015-02-20 | 2015-04-20 | 34SS+30d | 2012-12-28 | 2013-02-25 | 60d | 40d | 0d | 7,387,200,000 | 0% | 93/12/1 | 94/1/31 |
| 36 | 8.8 | اجرای کاشی و سرامیک |  | 60d | 2015-03-22 | 2015-05-20 | 35SS+30d | 2013-02-26 | 2013-04-26 | 60d | 40d |  | 7,387,200,000 | 0% | 94/1/2 | 94/2/30 |
| 37 | 9 | اجرای نما و نماسازی |  | 180d | 2014-10-18 | 2015-04-15 | 27, 23 | 2013-04-27 | 2013-11-22 | 210d | 91d |  | 22,129,200,000 | 0% | 93/7/26 | 94/1/26 |
| 38 | 10 | اجرای تأسیسات |  | 145d | 2015-01-01 | 2015-05-25 | 31 | 2013-04-27 | 2014-03-17 | 325d | 0d |  | 22,129,200,000 | 0% | 93/10/11 | 94/3/4 |
| 39 | 11 | نقاشی |  | 65d | 2015-04-26 | 2015-06-29 | 38FS-30d | 2013-09-24 | 2013-12-22 | 90d | 0d |  | 10,465,200,000 | 0% | 94/2/6 | 94/4/8 |
| 40 | 12 | تحویل موقت |  | 1d | 2015-06-30 | 2015-06-30 | 39, 36 | 2014-02-19 | 2014-03-20 | 30d | 0d |  |  | 0% | 94/4/9 | 94/4/9 |
| 41 | 13 | برچیدن کارگاه |  | 30d | 2015-06-16 | 2015-07-15 | 40FF+15d |  |  |  | 0d |  | 3,693,600,000 |  | 94/3/26 | 94/4/24 |
| 42 | 14 | پایان پروژه | milestone | 0d | 2015-07-15 | 2015-07-15 | 41, 2, 37 |  |  |  | 0d |  |  |  | 94/4/24 | 94/4/24 |
