# احداث مجموعه ورزشی

Schedule from MS Project, 2013-04-21 to 2015-11-22, status date 2013-05-20, costs in ریال.

## Calendars

- Standard: Mon-Sun 08:00-12:00, 13:00-17:00.

## Schedule

| ID | WBS | Task | Type | Duration | Start | Finish | Predecessors | Baseline start | Baseline finish | Baseline duration | Total slack | Free slack | Cost | Text1 | IN | OUT |
| --- | --- | --- | --- | --- | --- | --- | --- | --- | --- | --- | --- | --- | --- | --- | --- | --- |
| 1 | 1 | شروع پروژه (تحویل زمین) | milestone | 0d | 2013-04-21 | 2013-04-21 |  |  |  |  | 0d |  |  | 0% | 92/2/1 | 92/2/1 |
| 2 | 2 | تجهیز کارگاه |  | 30d | 2013-04-21 | 2013-05-20 | 1 |  |  |  | 916d |  | 36,000,000,000 | 0% | 92/2/1 | 92/2/30 |
| 3 | 3 | **طراحی و گودبرداری** |  | 90d | 2013-04-21 | 2013-07-19 |  | 2008-03-24 | 2008-07-21 | 120d | 0d |  | 14,774,400,000 | 0% |  |  |
| 4 | 3.1 | خاکبرداری |  | 60d | 2013-04-21 | 2013-06-19 | 1 | 2008-03-24 | 2008-05-22 | 60d | 0d |  | 7,387,200,000 | 0% | 92/2/1 | 92/3/29 |
| 5 | 3.2 | تسطیح و رگلاژ زمین |  | 60d | 2013-05-21 | 2013-07-19 | 4SS+30d | 2008-05-23 | 2008-07-21 | 60d | 0d |  | 7,387,200,000 | 0% | 92/2/31 | 92/4/28 |
| 6 | 4 | **فونداسیون** |  | 110d | 2013-05-31 | 2013-09-17 |  | 2008-07-22 | 2009-03-18 | 240d | 0d |  | 33,242,400,000 | 0% |  |  |
| 7 | 4.1 | اجرای بتن مگر |  | 60d | 2013-05-31 | 2013-07-29 | 5SS+10d | 2008-07-22 | 2008-09-19 | 60d | 0d |  | 7,387,200,000 | 0% | 92/3/10 | 92/5/7 |
| 8 | 4.2 | اجرای آرماتوربندی فونداسیون |  | 60d | 2013-06-05 | 2013-08-03 | 7SS+5d | 2008-09-20 | 2008-11-18 | 60d | 0d |  | 7,387,200,000 | 0% | 92/3/15 | 92/5/12 |
| 9 | 4.3 | اجرای قالب‌بندی فونداسیون |  | 60d | 2013-06-10 | 2013-08-08 | 8SS+5d | 2008-11-19 | 2009-01-17 | 60d | 0d |  | 7,387,200,000 | 0% | 92/3/20 | 92/5/17 |
| 10 | 4.4 | اجرای بتن‌ریزی فونداسیون |  | 60d | 2013-06-20 | 2013-08-18 | 9SS+10d | 2009-01-18 | 2009-02-16 | 30d | 0d |  | 7,387,200,000 | 0% | 92/3/30 | 92/5/27 |
| 11 | 4.5 | گروت ریزی و نصب صفحه ستون |  | 30d | 2013-08-19 | 2013-09-17 | 10 | 2009-02-17 | 2009-03-18 | 30d | 0d |  | 3,693,600,000 | 0% | 92/5/28 | 92/6/26 |
| 12 | 5 | **اسکلت** |  | 330d | 2013-09-18 | 2014-08-13 |  | 2009-03-19 | 2010-11-08 | 600d | 0d |  | 66,420,000,000 | 0% |  |  |
| 13 | 5.1 | اجرای بیس پلیت ستونها |  | 60d | 2013-09-18 | 2013-11-16 | 11 | 2009-03-19 | 2009-05-17 | 60d | 0d |  | 7,387,200,000 | 0% | 92/6/27 | 92/8/25 |
| 14 | 5.2 | ساخت و نصب ستون ها |  | 120d | 2013-10-18 | 2014-02-14 | 13SS+30d | 2009-05-18 | 2009-09-14 | 120d | 0d |  | 14,742,000,000 | 0% | 92/7/26 | 92/11/25 |
| 15 | 5.3 | ساخت و نصب تیرهای زنبوری و حمال |  | 120d | 2013-12-17 | 2014-04-15 | 14SS+60d | 2009-09-15 | 2010-01-12 | 120d | 0d |  | 14,742,000,000 | 0% | 92/9/26 | 93/1/26 |
| 16 | 5.4 | ساخت و نصب بادبندها |  | 60d | 2014-03-17 | 2014-05-15 | 15FS-30d | 2010-03-14 | 2010-05-12 | 60d | 0d |  | 7,387,200,000 | 0% | 92/12/26 | 93/2/25 |
| 17 | 5.5 | اجرای سقف شیبدار |  | 90d | 2014-04-16 | 2014-07-14 | 16SS+30d | 2010-05-13 | 2010-08-10 | 90d | 0d |  | 11,080,800,000 | 0% | 93/1/27 | 93/4/23 |
| 18 | 5.6 | اتصالات،جوشکاری و ضدزنگ |  | 90d | 2014-05-16 | 2014-08-13 | 17SS+30d | 2010-08-11 | 2010-11-08 | 90d | 0d |  | 11,080,800,000 | 0% | 93/2/26 | 93/5/22 |
| 19 | 6 | **سفت کاری** |  | 180d | 2014-05-31 | 2014-11-26 |  | 2010-11-09 | 2011-11-03 | 360d | 0d |  | 44,323,200,000 | 0% |  |  |
| 20 | 6.1 | خاکریزی پی و پشت دیوارها |  | 90d | 2014-05-31 | 2014-08-28 | 18SS+15d | 2010-11-09 | 2011-02-06 | 90d | 0d |  | 11,080,800,000 | 0% | 93/3/10 | 93/6/6 |
| 21 | 6.2 | اجرای دیوارچینی |  | 90d | 2014-06-30 | 2014-09-27 | 20SS+30d | 2011-02-07 | 2011-05-07 | 90d | 0d |  | 11,080,800,000 | 0% | 93/4/9 | 93/7/5 |
| 22 | 6.3 | ساخت ساب فریم درها و پنجره ها |  | 90d | 2014-07-30 | 2014-10-27 | 21SS+30d | 2011-05-08 | 2011-08-05 | 90d | 0d |  | 11,080,800,000 | 0% | 93/5/8 | 93/8/5 |
| 23 | 6.4 | نصب ساب فریم و درها و پنجره ها |  | 90d | 2014-08-29 | 2014-11-26 | 22SS+30d | 2011-08-06 | 2011-11-03 | 90d | 0d |  | 11,080,800,000 | 0% | 93/6/7 | 93/9/5 |
| 24 | 7 | **سقف سازی** |  | 330d | 2013-12-17 | 2014-11-11 |  | 2009-10-15 | 2010-09-09 | 330d | 196d |  | 40,338,000,000 | 0% |  |  |
| 25 | 7.1 | ساخت تیرچه های فلزی |  | 90d | 2013-12-17 | 2014-03-16 | 15SS | 2009-10-15 | 2010-01-12 | 90d | 196d | 0d | 11,080,800,000 | 0% | 92/9/26 | 92/12/25 |
| 26 | 7.2 | اجرای سقف |  | 150d | 2014-03-17 | 2014-08-13 | 25 | 2010-01-13 | 2010-06-11 | 150d | 196d | 0d | 18,176,400,000 | 0% | 92/12/26 | 93/5/22 |
| 27 | 7.3 | اجرای کنسولها و پله ها |  | 90d | 2014-08-14 | 2014-11-11 | 26 | 2010-06-12 | 2010-09-09 | 90d | 196d | 15d | 11,080,800,000 | 0% | 93/5/23 | 93/8/20 |

| ID | WBS | Task | Type | Duration | Start | Finish | Predecessors | Baseline start | Baseline finish | Baseline duration | Total slack | Free slack | Cost | Text1 | IN | OUT |
| --- | --- | --- | --- | --- | --- | --- | --- | --- | --- | --- | --- | --- | --- | --- | --- | --- |
| 28 | 8 | **نازک کاری** |  | 270d | 2014-10-18 | 2015-07-14 |  | 2011-11-04 | 2013-04-26 | 540d | 0d |  | 66,484,800,000 | 0% |  |  |
| 29 | 8.1 | نصب درب و پنجره وشیشه |  | 60d | 2014-10-18 | 2014-12-16 | 23SS+50d | 2011-11-04 | 2012-01-02 | 60d | 0d |  | 7,387,200,000 | 0% | 93/7/26 | 93/9/25 |
| 30 | 8.2 | سفيدکاری |  | 90d | 2014-11-17 | 2015-02-14 | 29SS+30d | 2012-01-03 | 2012-04-01 | 90d | 0d |  | 11,080,800,000 | 0% | 93/8/26 | 93/11/25 |
| 31 | 8.3 | زیرسازی و بتونه کشی دیوارها |  | 90d | 2014-12-17 | 2015-03-16 | 30SS+30d | 2012-04-02 | 2012-06-30 | 90d | 0d |  | 11,080,800,000 | 0% | 93/9/26 | 93/12/25 |
| 32 | 8.4 | عایق کاری سرویس ها |  | 60d | 2015-01-16 | 2015-03-16 | 31SS+30d | 2012-07-01 | 2012-08-29 | 60d | 115d | 0d | 7,387,200,000 | 0% | 93/10/26 | 93/12/25 |
| 33 | 8.5 | عایق کاری بام |  | 60d | 2015-02-15 | 2015-04-15 | 32SS+30d | 2012-08-30 | 2012-10-28 | 60d | 115d | 0d | 7,387,200,000 | 0% | 93/11/26 | 94/1/26 |
| 34 | 8.6 | کفسازی سرویس |  | 60d | 2015-03-17 | 2015-05-15 | 33SS+30d | 2012-10-29 | 2012-12-27 | 60d | 115d | 0d | 7,387,200,000 | 0% | 93/12/26 | 94/2/25 |
| 35 | 8.7 | کفسازی بام |  | 60d | 2015-04-16 | 2015-06-14 | 34SS+30d | 2012-12-28 | 2013-02-25 | 60d | 115d | 0d | 7,387,200,000 | 0% | 94/1/27 | 94/3/24 |
| 36 | 8.8 | اجرای کاشی و سرامیک |  | 60d | 2015-05-16 | 2015-07-14 | 35SS+30d | 2013-02-26 | 2013-04-26 | 60d | 115d |  | 7,387,200,000 | 0% | 94/2/26 | 94/4/23 |
| 37 | 9 | اجرای نما و نماسازی |  | 180d | 2014-11-27 | 2015-05-25 | 27, 23 | 2013-04-27 | 2013-11-22 | 210d | 181d |  | 22,129,200,000 | 0% | 93/9/6 | 94/3/4 |
| 38 | 10 | اجرای تأسیسات |  | 180d | 2015-03-17 | 2015-09-12 | 31 | 2013-04-27 | 2014-03-17 | 325d | 0d |  | 22,129,200,000 | 0% | 93/12/26 | 94/6/21 |
| 39 | 11 | نقاشی |  | 85d | 2015-08-14 | 2015-11-06 | 38FS-30d | 2013-09-24 | 2013-12-22 | 90d | 0d |  | 10,465,200,000 | 0% | 94/5/23 | 94/8/15 |
| 40 | 12 | تحویل موقت |  | 1d | 2015-11-07 | 2015-11-07 | 39, 36 | 2014-02-19 | 2014-03-20 | 30d | 0d |  |  | 0% | 94/8/16 | 94/8/16 |
| 41 | 13 | برچیدن کارگاه |  | 30d | 2015-10-24 | 2015-11-22 | 40FF+15d |  |  |  | 0d |  | 3,693,600,000 |  | 94/8/2 | 94/9/1 |
| 42 | 14 | پایان پروژه | milestone | 0d | 2015-11-22 | 2015-11-22 | 41, 2, 37 |  |  |  | 0d |  |  |  | 94/9/1 | 94/9/1 |
